# Autonomous Submersible

Schedule from MS Project, 2007-08-29 to 2008-05-20.
CSE 4316/4317
Team Barracuda

## Calendars

- Standard: Mon-Fri 08:00-12:00, 13:00-17:00; Sat-Sun off.

## Resources

| Resource |
| --- |
| McMurrough |
| Connelly |
| Break |
| Pham |
| Miller |
| All |
| Chris |
| Kevin |
| Braek |
| 125 |
| Oham |

## Schedule

| ID | WBS | Task | Duration | Start | Finish | Predecessors | Total slack | Free slack | Constraint | Resources | Work |
| --- | --- | --- | --- | --- | --- | --- | --- | --- | --- | --- | --- |
| 1 | 1 | **Phase 1** | 29d | 2007-10-25 | 2007-12-04 |  | 3d | 2d |  |  | 1264h |
| 2 | 1.1 | **Requirements Definition** | 28d | 2007-10-25 | 2007-12-03 |  | 4d |  |  |  | 624h |
| 3 | 1.1.1 | Requirements Worksheet | 1w | 2007-10-25 | 2007-10-31 |  | 9d | 0d |  |  |  |
| 4 | 1.1.2 | **SRD** | 12d | 2007-10-25 | 2007-11-09 |  | 10d | 0d |  |  | 416h |
| 5 | 1.1.2.1 | Initial SRD Draft | 1w | 2007-10-25 | 2007-10-31 |  | 24d | 0d |  | Pham | 40h |
| 6 | 1.1.2.2 | Complete Uses Cases section of SRD Draft | 1w | 2007-11-01 | 2007-11-07 | 5 | 24d | 0d |  | Break | 40h |
| 7 | 1.1.2.3 | Complete Assumptions section of SRD draft | 1w | 2007-11-01 | 2007-11-07 | 5 | 24d | 0d |  | Break | 40h |
| 8 | 1.1.2.4 | Complete Requirements section of SRD draft | 1w | 2007-11-01 | 2007-11-07 | 3, 5 | 24d | 0d |  | Connelly; Miller | 80h |
| 9 | 1.1.2.5 | Complete Exceptions section of SRD draft | 1w | 2007-11-01 | 2007-11-07 | 5 | 24d | 0d |  | Connelly | 40h |
| 10 | 1.1.2.6 | Complete Product Services and Summary section of SRD draft | 1w | 2007-11-01 | 2007-11-07 | 5 | 24d | 0d |  | Connelly | 40h |
| 11 | 1.1.2.7 | Complete Acceptance Criteria section of SRD draft | 1w | 2007-11-01 | 2007-11-07 | 5 | 24d | 0d |  | Pham | 40h |
| 12 | 1.1.2.8 | Complete External Interfaces and Data Flows section of SRD draft | 1w | 2007-11-01 | 2007-11-07 | 5 | 24d | 0d |  | Pham | 40h |
| 13 | 1.1.2.9 | Complete Environments section of SRD draft | 1w | 2007-11-01 | 2007-11-07 | 5 | 24d | 0d |  | Miller | 40h |
| 14 | 1.1.2.10 | Review final draft of SRD | 2d | 2007-11-08 | 2007-11-09 | 6, 7, 8, 9, 10, 11, 12, 13 | 24d |  |  | All | 16h |
| 15 | 1.1.3 | **Requirements Review** | 4d | 2007-11-12 | 2007-11-15 | 4 | 10d |  |  |  | 40h |
| 16 | 1.1.3.1 | SRD Posted online | 1d | 2007-11-12 | 2007-11-12 |  | 18d |  |  | McMurrough | 8h |
| 17 | 1.1.3.2 | Prepare SRD Presentation | 3d | 2007-11-12 | 2007-11-14 |  | 9d | 0d |  | McMurrough | 24h |
| 18 | 1.1.3.3 | Practice SRD presentation run-through | 1d | 2007-11-15 | 2007-11-15 | 17 | 24d | 0d |  | All | 8h |
| 19 | 1.1.4 | **SRD Version 2** | 12d | 2007-11-16 | 2007-12-03 | 18 | 4d |  |  |  | 168h |
| 20 | 1.1.4.1 | Add localization requirements | 3d | 2007-11-16 | 2007-11-20 |  | 27d |  |  | Break | 24h |
| 21 | 1.1.4.2 | Add system constraints | 3d | 2007-11-16 | 2007-11-20 |  | 27d |  |  | Pham | 24h |
| 22 | 1.1.4.3 | Add assumptions | 3d | 2007-11-16 | 2007-11-20 |  | 27d |  |  | Break | 24h |
| 23 | 1.1.4.4 | Create list of accepted suggested changes | 2d | 2007-11-16 | 2007-11-19 |  | 11d | 0d |  | McMurrough | 16h |
| 24 | 1.1.4.5 | Add suggested changes | 2d | 2007-11-20 | 2007-11-21 | 23 | 26d |  |  | Connelly; Miller | 32h |
| 25 | 1.1.4.6 | SRD Presentation 2 group review | 1d | 2007-11-26 | 2007-11-26 |  | 18d | 0d | start no earlier than 2007-11-26 | All | 8h |
| 26 | 1.1.4.7 | Individual presentation practice | 3d | 2007-11-27 | 2007-11-29 | 25 | 18d | 0d |  | All | 24h |
| 27 | 1.1.4.8 | Requirements Presentation 2 | 1d | 2007-11-30 | 2007-11-30 | 26 | 18d | 0d | start no earlier than 2007-11-30 | All | 8h |
| 28 | 1.1.4.9 | SRD 2 revision (if necessary) | 1d | 2007-12-03 | 2007-12-03 | 27 | 18d |  |  | All | 8h |

| ID | WBS | Task | Duration | Start | Finish | Predecessors | Total slack | Free slack | Constraint | Resources | Work |
| --- | --- | --- | --- | --- | --- | --- | --- | --- | --- | --- | --- |
| 29 | 1.2 | **Project Planning** | 5d | 2007-10-25 | 2007-10-31 |  | 27d |  |  |  | 80h |
| 30 | 1.2.1 | Project Schedule | 1w | 2007-10-25 | 2007-10-31 |  | 26d |  |  | McMurrough | 40h |
| 31 | 1.2.2 | MS Project | 1w | 2007-10-25 | 2007-10-31 |  | 26d |  |  | McMurrough | 40h |
| 32 | 1.3 | **Risk Management Plan** | 28d | 2007-10-26 | 2007-12-04 |  | 3d |  |  |  | 552h |
| 33 | 1.3.1 | Initial Risk Brainstorming | 1w | 2007-10-26 | 2007-11-01 |  | 22d | 0d | start no earlier than 2007-10-26 | All | 40h |
| 34 | 1.3.2 | Create Risk Management worksheet | 1w | 2007-11-02 | 2007-11-08 | 33 | 22d | 0d |  | Connelly | 40h |
| 35 | 1.3.3 | **Review / Refine Risk Management worksheet** | 2d | 2007-11-09 | 2007-11-12 | 34 | 16d | 0d |  |  | 80h |
| 36 | 1.3.3.1 | Review / Refine Risks 1-6 | 2d | 2007-11-09 | 2007-11-12 |  | 30d |  | start no earlier than 2007-11-09 | Pham | 16h |
| 37 | 1.3.3.2 | Review / Refine Risks 7-12 | 2d | 2007-11-09 | 2007-11-12 |  | 15d |  | start no earlier than 2007-11-09 | McMurrough | 16h |
| 38 | 1.3.3.3 | Review / Refine Risks 13-18 | 2d | 2007-11-09 | 2007-11-12 |  | 30d |  | start no earlier than 2007-11-09 | Miller | 16h |
| 39 | 1.3.3.4 | Review / Refine Risks 19-24 | 2d | 2007-11-09 | 2007-11-12 |  | 30d |  | start no earlier than 2007-11-09 | Break | 16h |
| 40 | 1.3.3.5 | Review / Refine Risks 25-30 | 2d | 2007-11-09 | 2007-11-12 |  | 30d |  | start no earlier than 2007-11-09 | Connelly | 16h |
| 41 | 1.3.4 | Updated Risk Management Draft (from project charter) | 3d | 2007-11-13 | 2007-11-15 | 43, 35 | 30d |  |  | Connelly | 24h |
| 42 | 1.3.5 | **Detailed risk management plan** | 10d | 2007-11-09 | 2007-11-22 | 34 | 7d | 0d |  |  | 272h |
| 43 | 1.3.5.1 | Quantify risks in risk worksheet | 2d | 2007-11-09 | 2007-11-12 |  | 29d | 0d |  | Pham | 16h |
| 44 | 1.3.5.2 | Identify top 10 risks | 1d | 2007-11-12 | 2007-11-12 |  | 21d | 0d | start no earlier than 2007-11-12 | Pham | 8h |
| 45 | 1.3.5.3 | **Create detailed plan for top 10 risks** | 3d | 2007-11-13 | 2007-11-15 | 44 | 7d | 0d |  |  | 48h |
| 46 | 1.3.5.3.1 | Detailed Risk Plan for Risk 1-5 | 3d | 2007-11-13 | 2007-11-15 |  | 21d |  |  | Break | 24h |
| 47 | 1.3.5.3.2 | Detailed Risk Pllan for Risk 6-10 | 3d | 2007-11-13 | 2007-11-15 |  | 21d |  |  | Miller | 24h |
| 48 | 1.3.5.4 | **Create detailed plan for remaining risks** | 5d | 2007-11-16 | 2007-11-22 | 45 | 7d |  |  |  | 200h |
| 49 | 1.3.5.4.1 | Detailed Risk Plan for risk set 1 | 1w | 2007-11-16 | 2007-11-22 |  | 21d |  |  | Pham | 40h |
| 50 | 1.3.5.4.2 | Detailed Risk Plan for risk set 2 | 1w | 2007-11-16 | 2007-11-22 |  | 21d |  |  | Miller | 40h |
| 51 | 1.3.5.4.3 | Detailed Risk Plan for risk set 3 | 1w | 2007-11-16 | 2007-11-22 |  | 21d |  |  | Break | 40h |
| 52 | 1.3.5.4.4 | Detailed Risk Plan for risk set 4 | 1w | 2007-11-16 | 2007-11-22 |  | 21d |  |  | Connelly | 40h |
| 53 | 1.3.5.4.5 | Detailed Risk Plan for risk set 5 | 1w | 2007-11-16 | 2007-11-22 |  | 6d | 0d |  | McMurrough | 40h |
| 54 | 1.3.6 | Final draft of Risk Management Plan | 4d | 2007-11-23 | 2007-11-28 | 42 | 21d |  |  | Connelly; Pham | 64h |
| 55 | 1.3.7 | Review final draft of Risk Management | 1d | 2007-11-23 | 2007-11-23 | 53 | 24d |  |  | All | 8h |
| 56 | 1.3.8 | Modifications to risk management plan | 3d | 2007-11-30 | 2007-12-04 |  | 17d |  | start no earlier than 2007-11-30 | All | 24h |
| 57 | 1.4 | Training session with team Neptune | 1d | 2007-12-03 | 2007-12-03 |  | 18d |  | start no earlier than 2007-12-03 | All | 8h |

| ID | WBS | Task | Duration | Start | Finish | Predecessors | Total slack | Constraint | Resources | Work |
| --- | --- | --- | --- | --- | --- | --- | --- | --- | --- | --- |
| 58 | 2 | **Phase 2** | 117.5d | 2007-12-07 | 2008-05-20 | 1 | 0d |  |  | 4448h |
| 59 | 2.1 | **Subsystem Research** | 20d | 2007-12-07 | 2008-01-03 |  | 98.5d |  |  | 800h |
| 60 | 2.1.1 | Hydrophone subsystem research | 4w | 2007-12-07 | 2008-01-03 |  | 87.5d | start no earlier than 2007-12-07 | Miller; McMurrough | 320h |
| 61 | 2.1.2 | Grappler subsystem research | 4w | 2007-12-07 | 2008-01-03 |  | 85d | start no earlier than 2007-12-07 | Break; Pham | 320h |
| 62 | 2.1.3 | Power subsystem research | 4w | 2007-12-07 | 2008-01-03 |  | 85d | start no earlier than 2007-12-07 | Connelly | 160h |
| 63 | 2.2 | **Architectural Design** | 45d | 2007-12-07 | 2008-02-07 |  | 0d |  |  | 800h |
| 64 | 2.2.1 | **ADS 1.0** | 39d | 2007-12-07 | 2008-01-30 |  | 0d |  |  | 760h |
| 65 | 2.2.1.1 | First layer ADS | 4w | 2007-12-07 | 2008-01-03 |  | 0d | start no earlier than 2007-12-07 | McMurrough | 160h |
| 66 | 2.2.1.2 | Second layer ADS | 1w | 2008-01-04 | 2008-01-10 | 65 | 0d | start no earlier than 2007-12-07 | All | 40h |
| 67 | 2.2.1.3 | **ADS Document Preparation** | 10d | 2008-01-11 | 2008-01-24 | 66 | 0d |  |  | 496h |
| 68 | 2.2.1.3.1 | Prepare ADS diagrams | 5d | 2008-01-11 | 2008-01-17 |  | 0d |  | McMurrough | 40h |
| 69 | 2.2.1.3.2 | Prepare ADS connection list and connection descriptions | 5d | 2008-01-11 | 2008-01-17 |  | 0d |  | Break | 40h |
| 70 | 2.2.1.3.3 | **ADS Layer Descriptions** | 5d | 2008-01-11 | 2008-01-17 |  | 0d |  |  | 120h |
| 71 | 2.2.1.3.3.1 | Mission Control / Internal Sensors / Base Stations layer descriptions | 5d | 2008-01-11 | 2008-01-17 |  | 0d |  | Pham | 40h |
| 72 | 2.2.1.3.3.2 | Objectives / Environmental Sensors / Environmental Devices layer descriptions | 5d | 2008-01-11 | 2008-01-17 |  | 0d |  | Miller | 40h |
| 73 | 2.2.1.3.3.3 | Behaviors / Kill Switch / Power System layer descriptions | 5d | 2008-01-11 | 2008-01-17 |  | 0d |  | Connelly | 40h |
| 74 | 2.2.1.3.4 | **ADS 1.0 document compilation** | 4d | 2008-01-18 | 2008-01-23 | 68, 69, 70 | 0d |  |  | 288h |
| 75 | 2.2.1.3.4.1 | Update ADS 1.0 Document Info | 2d | 2008-01-18 | 2008-01-21 |  | 0d |  | McMurrough | 16h |
| 76 | 2.2.1.3.4.2 | Update ADS 1.0 Base Station section | 2d | 2008-01-18 | 2008-01-21 |  | 0d |  | Pham | 16h |
| 77 | 2.2.1.3.4.3 | Update ADS 1.0 Mission Control section | 2d | 2008-01-18 | 2008-01-21 |  | 0d |  | Pham | 16h |
| 78 | 2.2.1.3.4.4 | Updates ADS 1.0 Kill Switch section | 2d | 2008-01-18 | 2008-01-21 |  | 0d |  | Connelly | 16h |
| 79 | 2.2.1.3.4.5 | Update ADS 1.0 Power System section | 2d | 2008-01-18 | 2008-01-21 |  | 0d |  | Connelly | 16h |
| 80 | 2.2.1.3.4.6 | Update ADS 1.0 Internal Sensors section | 2d | 2008-01-18 | 2008-01-21 |  | 0d |  | Pham | 16h |
| 81 | 2.2.1.3.4.7 | Update ADS 1.0 Objectives section | 2d | 2008-01-18 | 2008-01-21 |  | 0d |  | Miller | 16h |
| 82 | 2.2.1.3.4.8 | Update ADS 1.0 Environmental Sensors section | 2d | 2008-01-18 | 2008-01-21 |  | 0d |  | Miller | 16h |
| 83 | 2.2.1.3.4.9 | Update ADS 1.0 Environmental Devices section | 2d | 2008-01-18 | 2008-01-21 |  | 0d |  | Miller | 16h |
| 84 | 2.2.1.3.4.10 | Update ADS 1.0 Connection section | 2d | 2008-01-18 | 2008-01-21 |  | 64d |  | Break | 16h |
| 85 | 2.2.1.3.4.11 | Update ADS 1.0 Inter-Subsystem Data Flow section | 2d | 2008-01-18 | 2008-01-21 |  | 66.5d |  | McMurrough | 16h |
| 86 | 2.2.1.3.4.12 | Update ADS 1.0 Producer-Consumer Tables section | 2d | 2008-01-18 | 2008-01-21 |  | 64d |  | Break | 16h |
| 87 | 2.2.1.3.4.13 | Update ADS 1.0 Use Cases section | 2d | 2008-01-18 | 2008-01-21 |  | 64d |  | Break; Miller; Connelly | 48h |
| 88 | 2.2.1.3.4.14 | Update ADS 1.0 Data Dictionary section | 2d | 2008-01-18 | 2008-01-21 |  | 64d |  | Pham | 16h |
| 89 | 2.2.1.3.4.15 | Update ADS 1.0 Appendices section | 2d | 2008-01-18 | 2008-01-21 |  | 0d |  | Pham | 16h |
| 90 | 2.2.1.3.4.16 | Merge ADS 1.0 updated sections into complete document | 2d | 2008-01-22 | 2008-01-23 | 76, 77, 78, 79, 80, 81, 82, 83, 75, 89 | 0d |  | McMurrough | 16h |
| 91 | 2.2.1.3.5 | ADS 1.0 individual review | 1d | 2008-01-24 | 2008-01-24 | 90 | 61d |  | All | 8h |

| ID | WBS | Task | Duration | Start | Finish | Predecessors | Total slack | Free slack | Constraint | Resources | Work |
| --- | --- | --- | --- | --- | --- | --- | --- | --- | --- | --- | --- |
| 92 | 2.2.1.4 | **ADS Peer Review** | 4d | 2008-01-25 | 2008-01-30 | 67 | 74.5d |  |  |  | 64h |
| 93 | 2.2.1.4.1 | ADS submitted for review | 4d | 2008-01-25 | 2008-01-30 |  | 63.5d |  |  | McMurrough | 32h |
| 94 | 2.2.1.4.2 | **ADS Presentation** | 4d | 2008-01-25 | 2008-01-30 |  | 74.5d |  |  |  | 32h |
| 95 | 2.2.1.4.2.1 | Prepare ADS Presentation Slides | 3d | 2008-01-25 | 2008-01-29 |  | 63.5d | 0d |  | McMurrough | 24h |
| 96 | 2.2.1.4.2.2 | ADS Presentation Practice | 1d | 2008-01-30 | 2008-01-30 | 95 | 61d |  |  | All | 8h |
| 97 | 2.2.2 | **ADS 2.0** | 5d | 2008-02-01 | 2008-02-07 | 64 | 73.5d |  |  |  | 40h |
| 98 | 2.2.2.1 | Merge peer comments into single document | 2d | 2008-02-01 | 2008-02-04 |  | 62.5d | 0d | start no earlier than 2008-02-01 | McMurrough | 16h |
| 99 | 2.2.2.2 | Add necessary changes to ADS | 2d | 2008-02-05 | 2008-02-06 | 98 | 60d | 0d |  | Connelly | 16h |
| 100 | 2.2.2.3 | Prepare ADS 2.0 Presentation slides | 1d | 2008-02-07 | 2008-02-07 | 99 | 62.5d |  |  | McMurrough | 8h |
| 101 | 2.3 | **Detailed Design** | 16d | 2008-01-24 | 2008-02-14 |  | 0d |  |  |  | 1208h |
| 102 | 2.3.1 | **Initial DDS work** | 6d | 2008-01-24 | 2008-01-31 |  | 0d |  |  |  | 672h |
| 103 | 2.3.1.1 | Function list for System Health | 1.2w | 2008-01-24 | 2008-01-31 | 90 | 0d |  |  | Pham | 48h |
| 104 | 2.3.1.2 | Function list for Envinronmental Sensors | 1.2w | 2008-01-24 | 2008-01-31 | 90 | 0d |  |  | Miller | 48h |
| 105 | 2.3.1.3 | Function list for Environmental Devices | 1.2w | 2008-01-24 | 2008-01-31 | 90 | 0d |  |  | Break | 48h |
| 106 | 2.3.1.4 | Function list for Mission Control | 1.2w | 2008-01-24 | 2008-01-31 | 90 | 0d |  |  | Pham | 48h |
| 107 | 2.3.1.5 | Function list for Base Station | 1.2w | 2008-01-24 | 2008-01-31 | 90 | 0d |  |  | Pham | 48h |
| 108 | 2.3.1.6 | Function list for Objective Definition | 1.2w | 2008-01-24 | 2008-01-31 | 90 | 0d |  |  | Miller | 48h |
| 109 | 2.3.1.7 | Function list for Motion | 1.2w | 2008-01-24 | 2008-01-31 | 90 | 0d |  |  | Break | 48h |
| 110 | 2.3.1.8 | Function list for Act | 1.2w | 2008-01-24 | 2008-01-31 | 90 | 0d |  |  | Break | 48h |
| 111 | 2.3.1.9 | Function list for Validation Gate | 1.2w | 2008-01-24 | 2008-01-31 | 90 | 0d |  |  | Break | 48h |
| 112 | 2.3.1.10 | Function list for Flashing Buoy | 1.2w | 2008-01-24 | 2008-01-31 | 90 | 0d |  |  | Connelly | 48h |
| 113 | 2.3.1.11 | Function list for Pipeline Path | 1.2w | 2008-01-24 | 2008-01-31 | 90 | 0d |  |  | Connelly | 48h |
| 114 | 2.3.1.12 | Function list for Target Bin | 1.2w | 2008-01-24 | 2008-01-31 | 90 | 0d |  |  | Connelly | 48h |
| 115 | 2.3.1.13 | Function list for Acoustic Pinger | 1.2w | 2008-01-24 | 2008-01-31 | 90 | 0d |  |  | Miller | 48h |
| 116 | 2.3.1.14 | Function list for Treasure | 1.2w | 2008-01-24 | 2008-01-31 | 90 | 0d |  |  | Miller | 48h |

| ID | WBS | Task | Duration | Start | Finish | Predecessors | Total slack | Free slack | Resources | Work |
| --- | --- | --- | --- | --- | --- | --- | --- | --- | --- | --- |
| 117 | 2.3.2 | **DDS** | 10d | 2008-02-01 | 2008-02-14 | 102 | 0d |  |  | 536h |
| 118 | 2.3.2.1 | Update Base Station section of DDS | 0.8w | 2008-02-01 | 2008-02-06 |  | 15d | 0d | Pham | 32h |
| 119 | 2.3.2.2 | Update Mission Control section of DDS | 0.8w | 2008-02-01 | 2008-02-06 |  | 15d | 0d | Pham | 32h |
| 120 | 2.3.2.3 | Update Envinronmental Sensors section of DDS | 0.8w | 2008-02-01 | 2008-02-06 |  | 15d | 0d | Miller | 32h |
| 121 | 2.3.2.4 | Update Environmental Devices section of DDS | 0.8w | 2008-02-01 | 2008-02-06 |  | 15d | 0d | Break | 32h |
| 122 | 2.3.2.5 | **Update Objectives Section of DDS** | 5d | 2008-02-01 | 2008-02-07 |  | 0d |  |  | 200h |
| 123 | 2.3.2.5.1 | Update Objective Definition | 1w | 2008-02-01 | 2008-02-07 |  | 0d |  | Miller | 40h |
| 124 | 2.3.2.5.2 | Update Locate | 1w | 2008-02-01 | 2008-02-07 |  | 0d |  | Connelly; Miller | 80h |
| 125 | 2.3.2.5.3 | Update Motion | 1w | 2008-02-01 | 2008-02-07 |  | 0d |  | Break | 40h |
| 126 | 2.3.2.5.4 | Update Act | 1w | 2008-02-01 | 2008-02-07 |  | 0d |  | Break | 40h |
| 127 | 2.3.2.6 | Add System Health section to DDS | 1w | 2008-02-01 | 2008-02-07 |  | 38d | 4d | Pham | 40h |
| 128 | 2.3.2.7 | **Hardware systems design** | 4d | 2008-02-08 | 2008-02-13 | 122 | 0d |  |  | 160h |
| 129 | 2.3.2.7.1 | System Health Module design | 0.8w | 2008-02-08 | 2008-02-13 |  | 0d |  | McMurrough | 32h |
| 130 | 2.3.2.7.2 | Marker Dropper System design | 0.8w | 2008-02-08 | 2008-02-13 |  | 0d |  | Break | 32h |
| 131 | 2.3.2.7.3 | Hydrophone System design | 0.8w | 2008-02-08 | 2008-02-13 |  | 0d |  | Connelly | 32h |
| 132 | 2.3.2.7.4 | Grapple System design | 0.8w | 2008-02-08 | 2008-02-13 |  | 0d |  | Miller | 32h |
| 133 | 2.3.2.7.5 | Depth sensing design | 0.8w | 2008-02-08 | 2008-02-13 |  | 0d |  | Pham | 32h |
| 134 | 2.3.2.8 | DDS 1.0 Individual Review | 1d | 2008-02-14 | 2008-02-14 | 118, 119, 120, 121, 122, 127, 128 | 0d |  | All | 8h |
| 135 | 2.4 | **Implementation Phase** | 45d | 2008-02-15 | 2008-04-17 | 101 | 0d |  |  | 1640h |
| 136 | 2.4.1 | **Hardware Subsystems** | 30d | 2008-02-15 | 2008-03-27 |  | 0d |  |  | 1640h |
| 137 | 2.4.1.1 | **System Health Module** | 30d | 2008-02-15 | 2008-03-27 |  | 0d |  |  | 240h |
| 138 | 2.4.1.1.1 | System Health Module part sourcing | 1w | 2008-02-15 | 2008-02-21 |  | 0d |  | McMurrough | 40h |
| 139 | 2.4.1.1.2 | System Health Module Prototyping and Testing | 1w | 2008-02-22 | 2008-02-28 | 138 | 0d |  | McMurrough | 40h |
| 140 | 2.4.1.1.3 | System Health Module PCB Design | 1w | 2008-02-29 | 2008-03-06 | 139 | 0d |  | McMurrough | 40h |
| 141 | 2.4.1.1.4 | System Health Module fabrication | 1w | 2008-03-07 | 2008-03-13 | 140 | 0d |  | McMurrough | 40h |

| ID | WBS | Task | Duration | Start | Finish | Predecessors | Total slack | Resources | Work |
| --- | --- | --- | --- | --- | --- | --- | --- | --- | --- |
| 142 | 2.4.1.1.5 | **System Health Module integration** | 10d | 2008-03-14 | 2008-03-27 | 141 | 0d |  | 80h |
| 143 | 2.4.1.1.5.1 | System Health Module firmware | 1w | 2008-03-14 | 2008-03-20 |  | 0d | McMurrough | 40h |
| 144 | 2.4.1.1.5.2 | System Health Module software interface | 1w | 2008-03-21 | 2008-03-27 | 143 | 0d | McMurrough | 40h |
| 145 | 2.4.1.2 | **Marker Dropper System** | 30d | 2008-02-15 | 2008-03-27 |  | 0d |  | 240h |
| 146 | 2.4.1.2.1 | Marker Dropper System part sourcing | 1w | 2008-02-15 | 2008-02-21 |  | 0d | Break | 40h |
| 147 | 2.4.1.2.2 | Marker Dropper System Prototyping and Testing | 1w | 2008-02-22 | 2008-02-28 | 146 | 0d | Break | 40h |
| 148 | 2.4.1.2.3 | Marker Dropper System Final Design | 1w | 2008-02-29 | 2008-03-06 | 147 | 0d | Break | 40h |
| 149 | 2.4.1.2.4 | Marker Dropper System fabrication | 1w | 2008-03-07 | 2008-03-13 | 148 | 0d | Break | 40h |
| 150 | 2.4.1.2.5 | **Marker Dropper System integration** | 10d | 2008-03-14 | 2008-03-27 | 149 | 0d |  | 80h |
| 151 | 2.4.1.2.5.1 | Marker Dropper System firmware | 1w | 2008-03-14 | 2008-03-20 |  | 0d | McMurrough | 40h |
| 152 | 2.4.1.2.5.2 | Marker Dropper System software interface | 1w | 2008-03-21 | 2008-03-27 | 151 | 0d | McMurrough | 40h |
| 153 | 2.4.1.3 | **Hydrophone System** | 30d | 2008-02-15 | 2008-03-27 |  | 0d |  | 240h |
| 154 | 2.4.1.3.1 | Hyrdophone System part sourcing | 1w | 2008-02-15 | 2008-02-21 |  | 0d | Connelly | 40h |
| 155 | 2.4.1.3.2 | Hydrophone System Prototyping and Testing | 1w | 2008-02-22 | 2008-02-28 | 154 | 0d | Connelly | 40h |
| 156 | 2.4.1.3.3 | Hydrophone System PCB Design | 1w | 2008-02-29 | 2008-03-06 | 155 | 0d | Connelly | 40h |
| 157 | 2.4.1.3.4 | Hydrophone System fabrication | 1w | 2008-03-07 | 2008-03-13 | 156 | 0d | Connelly | 40h |
| 158 | 2.4.1.3.5 | **Hydrophone System integration** | 10d | 2008-03-14 | 2008-03-27 | 157 | 0d |  | 80h |
| 159 | 2.4.1.3.5.1 | Hydrophone System firmware | 1w | 2008-03-14 | 2008-03-20 |  | 0d | Connelly | 40h |
| 160 | 2.4.1.3.5.2 | Hydrophone System software interface | 1w | 2008-03-21 | 2008-03-27 | 159 | 0d | Connelly | 40h |
| 161 | 2.4.1.4 | **Grapple System** | 30d | 2008-02-15 | 2008-03-27 |  | 0d |  | 320h |
| 162 | 2.4.1.4.1 | Grapple System part sourcing | 1w | 2008-02-15 | 2008-02-21 |  | 0d | Miller | 40h |
| 163 | 2.4.1.4.2 | Grapple System Prototyping and Testing | 1w | 2008-02-22 | 2008-02-28 | 162 | 0d | Miller | 40h |
| 164 | 2.4.1.4.3 | Grapple System Final Design | 1w | 2008-02-29 | 2008-03-06 | 163 | 0d | Miller | 40h |
| 165 | 2.4.1.4.4 | Grapple System fabrication | 1w | 2008-03-07 | 2008-03-13 | 164 | 0d | Miller | 40h |
| 166 | 2.4.1.4.5 | Grapple System optimization | 1w | 2008-03-14 | 2008-03-20 | 165 | 0d | Miller | 40h |
| 167 | 2.4.1.4.6 | Grapple System Installation | 1w | 2008-03-21 | 2008-03-27 | 166 | 0d | Miller | 40h |

| ID | WBS | Task | Duration | Start | Finish | Predecessors | Total slack | Constraint | Resources | Work |
| --- | --- | --- | --- | --- | --- | --- | --- | --- | --- | --- |
| 168 | 2.4.1.4.7 | **Grapple System integration** | 10d | 2008-03-14 | 2008-03-27 | 165 | 0d |  |  | 80h |
| 169 | 2.4.1.4.7.1 | Grapple System firmware | 1w | 2008-03-14 | 2008-03-20 |  | 0d |  | McMurrough | 40h |
| 170 | 2.4.1.4.7.2 | Grapple System software interface | 1w | 2008-03-21 | 2008-03-27 | 169 | 0d |  | McMurrough | 40h |
| 171 | 2.4.1.5 | **Depth Sensing** | 30d | 2008-02-15 | 2008-03-27 |  | 0d |  |  | 240h |
| 172 | 2.4.1.5.1 | Depth Sensing part sourcing | 1w | 2008-02-15 | 2008-02-21 |  | 0d |  | Pham | 40h |
| 173 | 2.4.1.5.2 | Depth Sensing Prototyping and Testing | 1w | 2008-02-22 | 2008-02-28 | 172 | 0d |  | McMurrough | 40h |
| 174 | 2.4.1.5.3 | Depth Sensing Final Design | 1w | 2008-02-29 | 2008-03-06 | 173 | 0d |  | McMurrough | 40h |
| 175 | 2.4.1.5.4 | Depth Sensing fabrication | 1w | 2008-03-07 | 2008-03-13 | 174 | 0d |  | McMurrough | 40h |
| 176 | 2.4.1.5.5 | **Depth Sensing integration** | 10d | 2008-03-14 | 2008-03-27 | 175 | 0d |  |  | 80h |
| 177 | 2.4.1.5.5.1 | Depth Sensing firmware | 1w | 2008-03-14 | 2008-03-20 |  | 0d |  | McMurrough | 40h |
| 178 | 2.4.1.5.5.2 | Depth Sensing software interface | 1w | 2008-03-21 | 2008-03-27 | 177 | 0d |  | McMurrough | 40h |
| 179 | 2.4.1.6 | **Vision Subsystem** | 25d | 2008-02-22 | 2008-03-27 |  | 0d |  |  | 360h |
| 180 | 2.4.1.6.1 | Study current OpenCV Implementation | 1w | 2008-02-22 | 2008-02-28 |  | 0d | start no earlier than 2008-02-22 | Pham | 40h |
| 181 | 2.4.1.6.2 | Trace function calls of current OpenCV Implementation | 1w | 2008-02-29 | 2008-03-06 | 180 | 0d |  | Break | 40h |
| 182 | 2.4.1.6.3 | Create working demonstration of existing OpenCV system | 1w | 2008-03-07 | 2008-03-13 | 181 | 0d |  | Pham | 40h |
| 183 | 2.4.1.6.4 | Optimize OpenCV Implementation | 1w | 2008-03-14 | 2008-03-20 | 182 | 0d |  | Pham; Break | 80h |
| 184 | 2.4.1.6.5 | Complete vision recognition of flashing buoy | 1w | 2008-03-21 | 2008-03-27 | 183 | 0d |  | Pham; Break | 80h |
| 185 | 2.4.1.6.6 | Complete vision recognition of target bin | 1w | 2008-03-21 | 2008-03-27 | 183 | 0d |  | Pham; Break | 80h |
| 186 | 2.4.2 | **Software Objectives** | 15d | 2008-03-28 | 2008-04-17 | 136 | 0d |  |  |  |
| 187 | 2.4.2.1 | Validation Gate Objective | 3w | 2008-03-28 | 2008-04-17 |  | 0d |  |  |  |
| 188 | 2.4.2.2 | Start Buoy Objective | 3w | 2008-03-28 | 2008-04-17 |  | 0d |  |  |  |
| 189 | 2.4.2.3 | Target Bin Objective | 3w | 2008-03-28 | 2008-04-17 |  | 0d |  |  |  |
| 190 | 2.4.2.4 | Treasure Retrieval Objective | 3w | 2008-03-28 | 2008-04-17 |  | 0d |  |  |  |
| 191 | 2.5 | Product Testing | 3w | 2008-04-18 | 2008-05-08 | 135 | 0d |  |  |  |

| ID | WBS | Task | Duration | Start | Finish | Predecessors | Total slack | Constraint | Resources | Work |
| --- | --- | --- | --- | --- | --- | --- | --- | --- | --- | --- |
| 192 | 2.6 | **Project Closeout** | 7.5d | 2008-05-09 | 2008-05-20 | 191 | 0d |  |  |  |
| 193 | 2.6.1 | Final report and Presentation | 1.5w | 2008-05-09 | 2008-05-20 |  | 0d |  |  |  |
| 194 | 2.6.2 | Archive of all project artifacts | 1.5w | 2008-05-09 | 2008-05-20 |  | 0d |  |  |  |
| 195 | 3 | **Weekly Tasks** | 177d | 2007-08-29 | 2008-05-01 |  | 13.5d |  |  | 4696h |
| 196 | 3.1 | **Semester 1** | 99d | 2007-08-29 | 2008-01-14 |  | 91.5d |  |  | 4072h |
| 197 | 3.1.1 | **Team Meeting Agenda** | 71d | 2007-08-29 | 2007-12-05 |  | 119.5d |  | McMurrough | 680h |
| 198 | 3.1.1.1 | Team Meeting Agenda 1 | 1d | 2007-08-29 | 2007-08-29 |  | 189.5d | start no earlier than 2007-08-29 | McMurrough | 8h |
| 199 | 3.1.1.2 | Team Meeting Agenda 2 | 1d | 2007-09-05 | 2007-09-05 |  | 184.5d | start no earlier than 2007-09-05 | McMurrough | 8h |
| 200 | 3.1.1.3 | Team Meeting Agenda 3 | 1d | 2007-09-12 | 2007-09-12 |  | 179.5d | start no earlier than 2007-09-12 | McMurrough | 8h |
| 201 | 3.1.1.4 | Team Meeting Agenda 4 | 1d | 2007-09-19 | 2007-09-19 |  | 174.5d | start no earlier than 2007-09-19 | McMurrough | 8h |
| 202 | 3.1.1.5 | Team Meeting Agenda 5 | 1d | 2007-09-26 | 2007-09-26 |  | 169.5d | start no earlier than 2007-09-26 | McMurrough | 8h |
| 203 | 3.1.1.6 | Team Meeting Agenda 6 | 1d | 2007-10-03 | 2007-10-03 |  | 164.5d | start no earlier than 2007-10-03 | McMurrough | 8h |
| 204 | 3.1.1.7 | Team Meeting Agenda 7 | 1d | 2007-10-10 | 2007-10-10 |  | 159.5d | start no earlier than 2007-10-10 | McMurrough | 8h |
| 205 | 3.1.1.8 | Team Meeting Agenda 8 | 1d | 2007-10-17 | 2007-10-17 |  | 154.5d | start no earlier than 2007-10-17 | McMurrough | 8h |
| 206 | 3.1.1.9 | Team Meeting Agenda 9 | 1d | 2007-10-24 | 2007-10-24 |  | 149.5d | start no earlier than 2007-10-24 | McMurrough | 8h |
| 207 | 3.1.1.10 | Team Meeting Agenda 10 | 1d | 2007-10-31 | 2007-10-31 |  | 144.5d | start no earlier than 2007-10-31 | McMurrough | 8h |
| 208 | 3.1.1.11 | Team Meeting Agenda 11 | 1d | 2007-11-07 | 2007-11-07 |  | 139.5d | start no earlier than 2007-11-07 | McMurrough | 8h |
| 209 | 3.1.1.12 | Team Meeting Agenda 12 | 1d | 2007-11-14 | 2007-11-14 |  | 134.5d | start no earlier than 2007-11-14 | McMurrough | 8h |
| 210 | 3.1.1.13 | Team Meeting Agenda 14 | 1d | 2007-11-28 | 2007-11-28 |  | 124.5d | start no earlier than 2007-11-28 | McMurrough | 8h |
| 211 | 3.1.1.14 | Team Meeting Agenda 15 | 1d | 2007-12-05 | 2007-12-05 |  | 119.5d | start no earlier than 2007-12-05 | McMurrough | 8h |
| 212 | 3.1.2 | **Team Meeting** | 71d | 2007-08-30 | 2007-12-06 |  | 118.5d |  | All | 672h |
| 213 | 3.1.2.1 | Team Meeting 0 | 1d | 2007-08-30 | 2007-08-30 |  | 188.5d | start no earlier than 2007-08-30 | All | 8h |
| 214 | 3.1.2.2 | Team Meeting 1 | 1d | 2007-09-06 | 2007-09-06 |  | 183.5d | start no earlier than 2007-09-06 | All | 8h |
| 215 | 3.1.2.3 | Team Meeting 2 | 1d | 2007-09-13 | 2007-09-13 |  | 178.5d | start no earlier than 2007-09-13 | All | 8h |
| 216 | 3.1.2.4 | Team Meeting 3 | 1d | 2007-09-20 | 2007-09-20 |  | 173.5d | start no earlier than 2007-09-20 | All | 8h |
| 217 | 3.1.2.5 | Team Meeting 4 | 1d | 2007-09-27 | 2007-09-27 |  | 168.5d | start no earlier than 2007-09-27 | All | 8h |
| 218 | 3.1.2.6 | Team Meeting 5 | 1d | 2007-10-04 | 2007-10-04 |  | 163.5d | start no earlier than 2007-10-04 | All | 8h |
| 219 | 3.1.2.7 | Team Meeting 6 | 1d | 2007-10-11 | 2007-10-11 |  | 158.5d | start no earlier than 2007-10-11 | All | 8h |
| 220 | 3.1.2.8 | Team Meeting 7 | 1d | 2007-10-18 | 2007-10-18 |  | 153.5d | start no earlier than 2007-10-18 | All | 8h |
| 221 | 3.1.2.9 | Team Meeting 8 | 1d | 2007-10-25 | 2007-10-25 |  | 148.5d | start no earlier than 2007-10-25 | All | 8h |
| 222 | 3.1.2.10 | Team Meeting 9 | 1d | 2007-11-01 | 2007-11-01 |  | 143.5d | start no earlier than 2007-11-01 | All | 8h |
| 223 | 3.1.2.11 | Team Meeting 10 | 1d | 2007-11-08 | 2007-11-08 |  | 138.5d | start no earlier than 2007-11-08 | All | 8h |
| 224 | 3.1.2.12 | Team Meeting 12 | 1d | 2007-11-29 | 2007-11-29 |  | 123.5d | start no earlier than 2007-11-29 | All | 8h |
| 225 | 3.1.2.13 | Team Meeting 13 | 1d | 2007-12-06 | 2007-12-06 |  | 118.5d | start no earlier than 2007-12-06 | All | 8h |

| ID | WBS | Task | Duration | Start | Finish | Total slack | Constraint | Resources | Work |
| --- | --- | --- | --- | --- | --- | --- | --- | --- | --- |
| 226 | 3.1.3 | **Weekly Meeting Minutes** | 66d | 2007-08-30 | 2007-11-29 | 123.5d |  | Break | 624h |
| 227 | 3.1.3.1 | Weekly Meeting Minutes 1 | 1d | 2007-08-30 | 2007-08-30 | 188.5d | start no earlier than 2007-08-30 | Break | 8h |
| 228 | 3.1.3.2 | Weekly Meeting Minutes 2 | 1d | 2007-09-06 | 2007-09-06 | 183.5d | start no earlier than 2007-09-06 | Break | 8h |
| 229 | 3.1.3.3 | Weekly Meeting Minutes 3 | 1d | 2007-09-13 | 2007-09-13 | 178.5d | start no earlier than 2007-09-13 | Break | 8h |
| 230 | 3.1.3.4 | Weekly Meeting Minutes 4 | 1d | 2007-09-20 | 2007-09-20 | 173.5d | start no earlier than 2007-09-20 | Break | 8h |
| 231 | 3.1.3.5 | Weekly Meeting Minutes 5 | 1d | 2007-09-27 | 2007-09-27 | 168.5d | start no earlier than 2007-09-27 | Break | 8h |
| 232 | 3.1.3.6 | Weekly Meeting Minutes 6 | 1d | 2007-10-04 | 2007-10-04 | 163.5d | start no earlier than 2007-10-04 | Break | 8h |
| 233 | 3.1.3.7 | Weekly Meeting Minutes 7 | 1d | 2007-10-11 | 2007-10-11 | 158.5d | start no earlier than 2007-10-11 | Break | 8h |
| 234 | 3.1.3.8 | Weekly Meeting Minutes 8 | 1d | 2007-10-18 | 2007-10-18 | 153.5d | start no earlier than 2007-10-18 | Break | 8h |
| 235 | 3.1.3.9 | Weekly Meeting Minutes 9 | 1d | 2007-10-25 | 2007-10-25 | 148.5d | start no earlier than 2007-10-25 | Break | 8h |
| 236 | 3.1.3.10 | Weekly Meeting Minutes 10 | 1d | 2007-11-01 | 2007-11-01 | 143.5d | start no earlier than 2007-11-01 | Break | 8h |
| 237 | 3.1.3.11 | Weekly Meeting Minutes 11 | 1d | 2007-11-08 | 2007-11-08 | 138.5d | start no earlier than 2007-11-08 | Break | 8h |
| 238 | 3.1.3.12 | Weekly Meeting Minutes 14 | 1d | 2007-11-29 | 2007-11-29 | 123.5d | start no earlier than 2007-11-29 | Break | 8h |
| 239 | 3.1.4 | **Delegate to Neptune** | 71d | 2007-08-30 | 2007-12-06 | 118.5d |  | Miller | 680h |
| 240 | 3.1.4.1 | Delegate to Neptune 1 | 1d | 2007-08-30 | 2007-08-30 | 188.5d | start no earlier than 2007-08-30 | Miller | 8h |
| 241 | 3.1.4.2 | Delegate to Neptune 2 | 1d | 2007-09-06 | 2007-09-06 | 183.5d | start no earlier than 2007-09-06 | Miller | 8h |
| 242 | 3.1.4.3 | Delegate to Neptune 3 | 1d | 2007-09-13 | 2007-09-13 | 178.5d | start no earlier than 2007-09-13 | Miller | 8h |
| 243 | 3.1.4.4 | Delegate to Neptune 4 | 1d | 2007-09-20 | 2007-09-20 | 173.5d | start no earlier than 2007-09-20 | Miller | 8h |
| 244 | 3.1.4.5 | Delegate to Neptune 5 | 1d | 2007-09-27 | 2007-09-27 | 168.5d | start no earlier than 2007-09-27 | Miller | 8h |
| 245 | 3.1.4.6 | Delegate to Neptune 6 | 1d | 2007-10-04 | 2007-10-04 | 163.5d | start no earlier than 2007-10-04 | Miller | 8h |
| 246 | 3.1.4.7 | Delegate to Neptune 7 | 1d | 2007-10-11 | 2007-10-11 | 158.5d | start no earlier than 2007-10-11 | Miller | 8h |
| 247 | 3.1.4.8 | Delegate to Neptune 8 | 1d | 2007-10-18 | 2007-10-18 | 153.5d | start no earlier than 2007-10-18 | Miller | 8h |
| 248 | 3.1.4.9 | Delegate to Neptune 9 | 1d | 2007-10-25 | 2007-10-25 | 148.5d | start no earlier than 2007-10-25 | Miller | 8h |
| 249 | 3.1.4.10 | Delegate to Neptune 10 | 1d | 2007-11-01 | 2007-11-01 | 143.5d | start no earlier than 2007-11-01 | Miller | 8h |
| 250 | 3.1.4.11 | Delegate to Neptune 11 | 1d | 2007-11-08 | 2007-11-08 | 138.5d | start no earlier than 2007-11-08 | Miller | 8h |
| 251 | 3.1.4.12 | Delegate to Neptune 12 | 1d | 2007-11-15 | 2007-11-15 | 133.5d | start no earlier than 2007-11-15 | Miller | 8h |
| 252 | 3.1.4.13 | Delegate to Neptune 14 | 1d | 2007-11-29 | 2007-11-29 | 123.5d | start no earlier than 2007-11-29 | Miller | 8h |
| 253 | 3.1.4.14 | Delegate to Neptune 15 | 1d | 2007-12-06 | 2007-12-06 | 118.5d | start no earlier than 2007-12-06 | Miller | 8h |

| ID | WBS | Task | Duration | Start | Finish | Total slack | Constraint | Resources | Work |
| --- | --- | --- | --- | --- | --- | --- | --- | --- | --- |
| 254 | 3.1.5 | **Status reports / Friday Deliverables** | 71d | 2007-08-30 | 2007-12-06 | 118.5d |  | All | 688h |
| 255 | 3.1.5.1 | Status reports / Friday Deliverables 1 | 1d | 2007-08-30 | 2007-08-30 | 188.5d | start no earlier than 2007-08-30 | All | 8h |
| 256 | 3.1.5.2 | Status reports / Friday Deliverables 2 | 1d | 2007-09-06 | 2007-09-06 | 183.5d | start no earlier than 2007-09-06 | All | 8h |
| 257 | 3.1.5.3 | Status reports / Friday Deliverables 3 | 1d | 2007-09-13 | 2007-09-13 | 178.5d | start no earlier than 2007-09-13 | All | 8h |
| 258 | 3.1.5.4 | Status reports / Friday Deliverables 4 | 1d | 2007-09-20 | 2007-09-20 | 173.5d | start no earlier than 2007-09-20 | All | 8h |
| 259 | 3.1.5.5 | Status reports / Friday Deliverables 5 | 1d | 2007-09-27 | 2007-09-27 | 168.5d | start no earlier than 2007-09-27 | All | 8h |
| 260 | 3.1.5.6 | Status reports / Friday Deliverables 6 | 1d | 2007-10-04 | 2007-10-04 | 163.5d | start no earlier than 2007-10-04 | All | 8h |
| 261 | 3.1.5.7 | Status reports / Friday Deliverables 7 | 1d | 2007-10-11 | 2007-10-11 | 158.5d | start no earlier than 2007-10-11 | All | 8h |
| 262 | 3.1.5.8 | Status reports / Friday Deliverables 8 | 1d | 2007-10-18 | 2007-10-18 | 153.5d | start no earlier than 2007-10-18 | All | 8h |
| 263 | 3.1.5.9 | Status reports / Friday Deliverables 9 | 1d | 2007-10-25 | 2007-10-25 | 148.5d | start no earlier than 2007-10-25 | All | 8h |
| 264 | 3.1.5.10 | Status reports / Friday Deliverables 10 | 1d | 2007-11-01 | 2007-11-01 | 143.5d | start no earlier than 2007-11-01 | All | 8h |
| 265 | 3.1.5.11 | Status reports / Friday Deliverables 11 | 1d | 2007-11-08 | 2007-11-08 | 138.5d | start no earlier than 2007-11-08 | All | 8h |
| 266 | 3.1.5.12 | Status reports / Friday Deliverables 12 | 1d | 2007-11-15 | 2007-11-15 | 133.5d | start no earlier than 2007-11-15 | All | 8h |
| 267 | 3.1.5.13 | Status reports / Friday Deliverables 13 | 1d | 2007-11-22 | 2007-11-22 | 128.5d | start no earlier than 2007-11-22 | All | 8h |
| 268 | 3.1.5.14 | Status reports / Friday Deliverables 14 | 1d | 2007-11-29 | 2007-11-29 | 123.5d | start no earlier than 2007-11-29 | All | 8h |
| 269 | 3.1.5.15 | Status reports / Friday Deliverables 15 | 1d | 2007-12-06 | 2007-12-06 | 118.5d | start no earlier than 2007-12-06 | All | 8h |
| 270 | 3.1.6 | **Status Report Presentation** | 71d | 2007-08-30 | 2007-12-06 | 118.5d |  | McMurrough | 672h |
| 271 | 3.1.6.1 | Status Report Presentation 1 | 1d | 2007-08-30 | 2007-08-30 | 188.5d | start no earlier than 2007-08-30 | McMurrough | 8h |
| 272 | 3.1.6.2 | Status Report Presentation 2 | 1d | 2007-09-06 | 2007-09-06 | 183.5d | start no earlier than 2007-09-06 | McMurrough | 8h |
| 273 | 3.1.6.3 | Status Report Presentation 3 | 1d | 2007-09-13 | 2007-09-13 | 178.5d | start no earlier than 2007-09-13 | McMurrough | 8h |
| 274 | 3.1.6.4 | Status Report Presentation 4 | 1d | 2007-09-20 | 2007-09-20 | 173.5d | start no earlier than 2007-09-20 | McMurrough | 8h |
| 275 | 3.1.6.5 | Status Report Presentation 5 | 1d | 2007-09-27 | 2007-09-27 | 168.5d | start no earlier than 2007-09-27 | McMurrough | 8h |
| 276 | 3.1.6.6 | Status Report Presentation 6 | 1d | 2007-10-04 | 2007-10-04 | 163.5d | start no earlier than 2007-10-04 | McMurrough | 8h |
| 277 | 3.1.6.7 | Status Report Presentation 7 | 1d | 2007-10-11 | 2007-10-11 | 158.5d | start no earlier than 2007-10-11 | McMurrough | 8h |
| 278 | 3.1.6.8 | Status Report Presentation 8 | 1d | 2007-10-18 | 2007-10-18 | 153.5d | start no earlier than 2007-10-18 | McMurrough | 8h |
| 279 | 3.1.6.9 | Status Report Presentation 9 | 1d | 2007-10-25 | 2007-10-25 | 148.5d | start no earlier than 2007-10-25 | McMurrough | 8h |
| 280 | 3.1.6.10 | Status Report Presentation 10 | 1d | 2007-11-01 | 2007-11-01 | 143.5d | start no earlier than 2007-11-01 | McMurrough | 8h |
| 281 | 3.1.6.11 | Status Report Presentation 11 | 1d | 2007-11-08 | 2007-11-08 | 138.5d | start no earlier than 2007-11-08 | McMurrough | 8h |
| 282 | 3.1.6.12 | Status Report Presentation 14 | 1d | 2007-11-29 | 2007-11-29 | 123.5d | start no earlier than 2007-11-29 | McMurrough | 8h |
| 283 | 3.1.6.13 | Status Report Presentation 15 | 1d | 2007-12-06 | 2007-12-06 | 118.5d | start no earlier than 2007-12-06 | McMurrough | 8h |

| ID | WBS | Task | Duration | Start | Finish | Total slack | Constraint | Resources | Work |
| --- | --- | --- | --- | --- | --- | --- | --- | --- | --- |
| 284 | 3.1.7 | **Holiday break meetings** | 9d | 2008-01-02 | 2008-01-14 | 91.5d |  |  | 56h |
| 285 | 3.1.7.1 | Holiday Team Meeting 1 | 1d | 2008-01-03 | 2008-01-03 | 98.5d | start no earlier than 2008-01-03 | All | 8h |
| 286 | 3.1.7.2 | Holiday Team Meeting 2 | 1d | 2008-01-10 | 2008-01-10 | 93.5d | start no earlier than 2008-01-10 | All | 8h |
| 287 | 3.1.7.3 | Holiday Agenda 1 | 1d | 2008-01-02 | 2008-01-02 | 99.5d | start no earlier than 2008-01-02 | McMurrough | 8h |
| 288 | 3.1.7.4 | Holiday Agenda 2 | 1d | 2008-01-09 | 2008-01-09 | 94.5d | start no earlier than 2008-01-09 | McMurrough | 8h |
| 289 | 3.1.7.5 | Holiday Minutes 1 | 1d | 2008-01-03 | 2008-01-03 | 98.5d | start no earlier than 2008-01-03 | Break | 8h |
| 290 | 3.1.7.6 | Holiday Minutes 2 | 1d | 2008-01-10 | 2008-01-10 | 93.5d | start no earlier than 2008-01-10 | Break | 8h |
| 291 | 3.1.7.7 | Holiday status report / deliverables | 1d | 2008-01-14 | 2008-01-14 | 91.5d | start no earlier than 2008-01-14 | All | 8h |
| 292 | 3.2 | **Semester 2** | 77d | 2008-01-16 | 2008-05-01 | 13.5d |  |  | 624h |
| 293 | 3.2.1 | **Weekly Meeting Agenda** | 76d | 2008-01-16 | 2008-04-30 | 14.5d |  |  | 120h |
| 294 | 3.2.1.1 | Weekly Meeting Agenda 1 | 0.2w | 2008-01-16 | 2008-01-16 | 89.5d | start no earlier than 2008-01-16 | McMurrough | 8h |
| 295 | 3.2.1.2 | Weekly Meeting Agenda 2 | 0.2w | 2008-01-23 | 2008-01-23 | 84.5d | start no earlier than 2008-01-23 | McMurrough | 8h |
| 296 | 3.2.1.3 | Weekly Meeting Agenda 3 | 0.2w | 2008-01-30 | 2008-01-30 | 79.5d | start no earlier than 2008-01-30 | McMurrough | 8h |
| 297 | 3.2.1.4 | Weekly Meeting Agenda 4 | 0.2w | 2008-02-06 | 2008-02-06 | 74.5d | start no earlier than 2008-02-06 | McMurrough | 8h |
| 298 | 3.2.1.5 | Weekly Meeting Agenda 5 | 0.2w | 2008-02-13 | 2008-02-13 | 69.5d | start no earlier than 2008-02-13 | McMurrough | 8h |
| 299 | 3.2.1.6 | Weekly Meeting Agenda 6 | 0.2w | 2008-02-20 | 2008-02-20 | 64.5d | start no earlier than 2008-02-20 | McMurrough | 8h |
| 300 | 3.2.1.7 | Weekly Meeting Agenda 7 | 0.2w | 2008-02-27 | 2008-02-27 | 59.5d | start no earlier than 2008-02-27 | McMurrough | 8h |
| 301 | 3.2.1.8 | Weekly Meeting Agenda 8 | 0.2w | 2008-03-05 | 2008-03-05 | 54.5d | start no earlier than 2008-03-05 | McMurrough | 8h |
| 302 | 3.2.1.9 | Weekly Meeting Agenda 9 | 0.2w | 2008-03-12 | 2008-03-12 | 49.5d | start no earlier than 2008-03-12 | McMurrough | 8h |
| 303 | 3.2.1.10 | Weekly Meeting Agenda 10 | 0.2w | 2008-03-19 | 2008-03-19 | 44.5d | start no earlier than 2008-03-19 | McMurrough | 8h |
| 304 | 3.2.1.11 | Weekly Meeting Agenda 11 | 0.2w | 2008-03-26 | 2008-03-26 | 39.5d | start no earlier than 2008-03-26 | McMurrough | 8h |
| 305 | 3.2.1.12 | Weekly Meeting Agenda 12 | 0.2w | 2008-04-02 | 2008-04-02 | 34.5d | start no earlier than 2008-04-02 | McMurrough | 8h |
| 306 | 3.2.1.13 | Weekly Meeting Agenda 13 | 0.2w | 2008-04-09 | 2008-04-09 | 29.5d | start no earlier than 2008-04-09 | McMurrough | 8h |
| 307 | 3.2.1.14 | Weekly Meeting Agenda 14 | 0.2w | 2008-04-16 | 2008-04-16 | 24.5d | start no earlier than 2008-04-16 | McMurrough | 8h |
| 308 | 3.2.1.15 | Weekly Meeting Agenda 15 | 0.2w | 2008-04-23 | 2008-04-23 | 19.5d | start no earlier than 2008-04-23 | McMurrough | 8h |
| 309 | 3.2.1.16 | Weekly Meeting Agenda 16 | 0.2w | 2008-04-30 | 2008-04-30 | 14.5d | start no earlier than 2008-04-30 |  |  |

| ID | WBS | Task | Duration | Start | Finish | Total slack | Constraint | Resources | Work |
| --- | --- | --- | --- | --- | --- | --- | --- | --- | --- |
| 310 | 3.2.2 | **Weekly Meeting** | 76d | 2008-01-16 | 2008-04-30 | 14.5d |  |  | 120h |
| 311 | 3.2.2.1 | Weekly Meeting 1 | 0.2w | 2008-01-16 | 2008-01-16 | 89.5d | start no earlier than 2008-01-16 | All | 8h |
| 312 | 3.2.2.2 | Weekly Meeting 2 | 0.2w | 2008-01-23 | 2008-01-23 | 84.5d | start no earlier than 2008-01-23 | All | 8h |
| 313 | 3.2.2.3 | Weekly Meeting 3 | 0.2w | 2008-01-30 | 2008-01-30 | 79.5d | start no earlier than 2008-01-30 | All | 8h |
| 314 | 3.2.2.4 | Weekly Meeting 4 | 0.2w | 2008-02-06 | 2008-02-06 | 74.5d | start no earlier than 2008-02-06 | All | 8h |
| 315 | 3.2.2.5 | Weekly Meeting 5 | 0.2w | 2008-02-13 | 2008-02-13 | 69.5d | start no earlier than 2008-02-13 | All | 8h |
| 316 | 3.2.2.6 | Weekly Meeting 6 | 0.2w | 2008-02-20 | 2008-02-20 | 64.5d | start no earlier than 2008-02-20 | All | 8h |
| 317 | 3.2.2.7 | Weekly Meeting 7 | 0.2w | 2008-02-27 | 2008-02-27 | 59.5d | start no earlier than 2008-02-27 | All | 8h |
| 318 | 3.2.2.8 | Weekly Meeting 8 | 0.2w | 2008-03-05 | 2008-03-05 | 54.5d | start no earlier than 2008-03-05 | All | 8h |
| 319 | 3.2.2.9 | Weekly Meeting 9 | 0.2w | 2008-03-12 | 2008-03-12 | 49.5d | start no earlier than 2008-03-12 | All | 8h |
| 320 | 3.2.2.10 | Weekly Meeting 10 | 0.2w | 2008-03-19 | 2008-03-19 | 44.5d | start no earlier than 2008-03-19 | All | 8h |
| 321 | 3.2.2.11 | Weekly Meeting 11 | 0.2w | 2008-03-26 | 2008-03-26 | 39.5d | start no earlier than 2008-03-26 | All | 8h |
| 322 | 3.2.2.12 | Weekly Meeting 12 | 0.2w | 2008-04-02 | 2008-04-02 | 34.5d | start no earlier than 2008-04-02 | All | 8h |
| 323 | 3.2.2.13 | Weekly Meeting 13 | 0.2w | 2008-04-09 | 2008-04-09 | 29.5d | start no earlier than 2008-04-09 | All | 8h |
| 324 | 3.2.2.14 | Weekly Meeting 14 | 0.2w | 2008-04-16 | 2008-04-16 | 24.5d | start no earlier than 2008-04-16 | All | 8h |
| 325 | 3.2.2.15 | Weekly Meeting 15 | 0.2w | 2008-04-23 | 2008-04-23 | 19.5d | start no earlier than 2008-04-23 | All | 8h |
| 326 | 3.2.2.16 | Weekly Meeting 16 | 0.2w | 2008-04-30 | 2008-04-30 | 14.5d | start no earlier than 2008-04-30 |  |  |
| 327 | 3.2.3 | **Weekly Meeting Minutes** | 76d | 2008-01-17 | 2008-05-01 | 13.5d |  |  | 128h |
| 328 | 3.2.3.1 | Weekly Meeting Minutes 1 | 0.2w | 2008-01-17 | 2008-01-17 | 88.5d | start no earlier than 2008-01-17 | Break | 8h |
| 329 | 3.2.3.2 | Weekly Meeting Minutes 2 | 0.2w | 2008-01-24 | 2008-01-24 | 83.5d | start no earlier than 2008-01-24 | Break | 8h |
| 330 | 3.2.3.3 | Weekly Meeting Minutes 3 | 0.2w | 2008-01-31 | 2008-01-31 | 78.5d | start no earlier than 2008-01-31 | Break | 8h |
| 331 | 3.2.3.4 | Weekly Meeting Minutes 4 | 0.2w | 2008-02-07 | 2008-02-07 | 73.5d | start no earlier than 2008-02-07 | Break | 8h |
| 332 | 3.2.3.5 | Weekly Meeting Minutes 5 | 0.2w | 2008-02-14 | 2008-02-14 | 68.5d | start no earlier than 2008-02-14 | Break | 8h |
| 333 | 3.2.3.6 | Weekly Meeting Minutes 6 | 0.2w | 2008-02-21 | 2008-02-21 | 63.5d | start no earlier than 2008-02-21 | Break | 8h |
| 334 | 3.2.3.7 | Weekly Meeting Minutes 7 | 0.2w | 2008-02-28 | 2008-02-28 | 58.5d | start no earlier than 2008-02-28 | Break | 8h |
| 335 | 3.2.3.8 | Weekly Meeting Minutes 8 | 0.2w | 2008-03-06 | 2008-03-06 | 53.5d | start no earlier than 2008-03-06 | Break | 8h |
| 336 | 3.2.3.9 | Weekly Meeting Minutes 9 | 0.2w | 2008-03-13 | 2008-03-13 | 48.5d | start no earlier than 2008-03-13 | Break | 8h |
| 337 | 3.2.3.10 | Weekly Meeting Minutes 10 | 0.2w | 2008-03-20 | 2008-03-20 | 43.5d | start no earlier than 2008-03-20 | Break | 8h |
| 338 | 3.2.3.11 | Weekly Meeting Minutes 11 | 0.2w | 2008-03-27 | 2008-03-27 | 38.5d | start no earlier than 2008-03-27 | Break | 8h |
| 339 | 3.2.3.12 | Weekly Meeting Minutes 12 | 0.2w | 2008-04-03 | 2008-04-03 | 33.5d | start no earlier than 2008-04-03 | Break | 8h |
| 340 | 3.2.3.13 | Weekly Meeting Minutes 13 | 0.2w | 2008-04-10 | 2008-04-10 | 28.5d | start no earlier than 2008-04-10 | Break | 8h |
| 341 | 3.2.3.14 | Weekly Meeting Minutes 14 | 0.2w | 2008-04-17 | 2008-04-17 | 23.5d | start no earlier than 2008-04-17 | Break | 8h |
| 342 | 3.2.3.15 | Weekly Meeting Minutes 15 | 0.2w | 2008-04-24 | 2008-04-24 | 18.5d | start no earlier than 2008-04-24 | Break | 8h |
| 343 | 3.2.3.16 | Weekly Meeting Minutes 16 | 0.2w | 2008-05-01 | 2008-05-01 | 13.5d | start no earlier than 2008-05-01 | Break | 8h |

| ID | WBS | Task | Duration | Start | Finish | Total slack | Constraint | Resources | Work |
| --- | --- | --- | --- | --- | --- | --- | --- | --- | --- |
| 344 | 3.2.4 | **Status reports / Friday Deliverables** | 76d | 2008-01-17 | 2008-05-01 | 13.5d |  |  | 128h |
| 345 | 3.2.4.1 | Status reports / Friday Deliverables 1 | 0.2w | 2008-01-17 | 2008-01-17 | 88.5d | start no earlier than 2008-01-17 | All | 8h |
| 346 | 3.2.4.2 | Status reports / Friday Deliverables 2 | 0.2w | 2008-01-24 | 2008-01-24 | 83.5d | start no earlier than 2008-01-24 | All | 8h |
| 347 | 3.2.4.3 | Status reports / Friday Deliverables 3 | 0.2w | 2008-01-31 | 2008-01-31 | 78.5d | start no earlier than 2008-01-31 | All | 8h |
| 348 | 3.2.4.4 | Status reports / Friday Deliverables 4 | 0.2w | 2008-02-07 | 2008-02-07 | 73.5d | start no earlier than 2008-02-07 | All | 8h |
| 349 | 3.2.4.5 | Status reports / Friday Deliverables 5 | 0.2w | 2008-02-14 | 2008-02-14 | 68.5d | start no earlier than 2008-02-14 | All | 8h |
| 350 | 3.2.4.6 | Status reports / Friday Deliverables 6 | 0.2w | 2008-02-21 | 2008-02-21 | 63.5d | start no earlier than 2008-02-21 | All | 8h |
| 351 | 3.2.4.7 | Status reports / Friday Deliverables 7 | 0.2w | 2008-02-28 | 2008-02-28 | 58.5d | start no earlier than 2008-02-28 | All | 8h |
| 352 | 3.2.4.8 | Status reports / Friday Deliverables 8 | 0.2w | 2008-03-06 | 2008-03-06 | 53.5d | start no earlier than 2008-03-06 | All | 8h |
| 353 | 3.2.4.9 | Status reports / Friday Deliverables 9 | 0.2w | 2008-03-13 | 2008-03-13 | 48.5d | start no earlier than 2008-03-13 | All | 8h |
| 354 | 3.2.4.10 | Status reports / Friday Deliverables 10 | 0.2w | 2008-03-20 | 2008-03-20 | 43.5d | start no earlier than 2008-03-20 | All | 8h |
| 355 | 3.2.4.11 | Status reports / Friday Deliverables 11 | 0.2w | 2008-03-27 | 2008-03-27 | 38.5d | start no earlier than 2008-03-27 | All | 8h |
| 356 | 3.2.4.12 | Status reports / Friday Deliverables 12 | 0.2w | 2008-04-03 | 2008-04-03 | 33.5d | start no earlier than 2008-04-03 | All | 8h |
| 357 | 3.2.4.13 | Status reports / Friday Deliverables 13 | 0.2w | 2008-04-10 | 2008-04-10 | 28.5d | start no earlier than 2008-04-10 | All | 8h |
| 358 | 3.2.4.14 | Status reports / Friday Deliverables 14 | 0.2w | 2008-04-17 | 2008-04-17 | 23.5d | start no earlier than 2008-04-17 | All | 8h |
| 359 | 3.2.4.15 | Status reports / Friday Deliverables 15 | 0.2w | 2008-04-24 | 2008-04-24 | 18.5d | start no earlier than 2008-04-24 | All | 8h |
| 360 | 3.2.4.16 | Status reports / Friday Deliverables 16 | 0.2w | 2008-05-01 | 2008-05-01 | 13.5d | start no earlier than 2008-05-01 | All | 8h |
| 361 | 3.2.5 | **Status Report Presentation** | 76d | 2008-01-17 | 2008-05-01 | 13.5d |  |  | 128h |
| 362 | 3.2.5.1 | Status Report Presentation 1 | 0.2w | 2008-01-17 | 2008-01-17 | 88.5d | start no earlier than 2008-01-17 | McMurrough | 8h |
| 363 | 3.2.5.2 | Status Report Presentation 2 | 0.2w | 2008-01-24 | 2008-01-24 | 83.5d | start no earlier than 2008-01-24 | McMurrough | 8h |
| 364 | 3.2.5.3 | Status Report Presentation 3 | 0.2w | 2008-01-31 | 2008-01-31 | 78.5d | start no earlier than 2008-01-31 | McMurrough | 8h |
| 365 | 3.2.5.4 | Status Report Presentation 4 | 0.2w | 2008-02-07 | 2008-02-07 | 73.5d | start no earlier than 2008-02-07 | McMurrough | 8h |
| 366 | 3.2.5.5 | Status Report Presentation 5 | 0.2w | 2008-02-14 | 2008-02-14 | 68.5d | start no earlier than 2008-02-14 | McMurrough | 8h |
| 367 | 3.2.5.6 | Status Report Presentation 6 | 0.2w | 2008-02-21 | 2008-02-21 | 63.5d | start no earlier than 2008-02-21 | McMurrough | 8h |
| 368 | 3.2.5.7 | Status Report Presentation 7 | 0.2w | 2008-02-28 | 2008-02-28 | 58.5d | start no earlier than 2008-02-28 | McMurrough | 8h |
| 369 | 3.2.5.8 | Status Report Presentation 8 | 0.2w | 2008-03-06 | 2008-03-06 | 53.5d | start no earlier than 2008-03-06 | McMurrough | 8h |
| 370 | 3.2.5.9 | Status Report Presentation 9 | 0.2w | 2008-03-13 | 2008-03-13 | 48.5d | start no earlier than 2008-03-13 | McMurrough | 8h |
| 371 | 3.2.5.10 | Status Report Presentation 10 | 0.2w | 2008-03-20 | 2008-03-20 | 43.5d | start no earlier than 2008-03-20 | McMurrough | 8h |
| 372 | 3.2.5.11 | Status Report Presentation 11 | 0.2w | 2008-03-27 | 2008-03-27 | 38.5d | start no earlier than 2008-03-27 | McMurrough | 8h |
| 373 | 3.2.5.12 | Status Report Presentation 12 | 0.2w | 2008-04-03 | 2008-04-03 | 33.5d | start no earlier than 2008-04-03 | McMurrough | 8h |
| 374 | 3.2.5.13 | Status Report Presentation 13 | 0.2w | 2008-04-10 | 2008-04-10 | 28.5d | start no earlier than 2008-04-10 | McMurrough | 8h |
| 375 | 3.2.5.14 | Status Report Presentation 14 | 0.2w | 2008-04-17 | 2008-04-17 | 23.5d | start no earlier than 2008-04-17 | McMurrough | 8h |
| 376 | 3.2.5.15 | Status Report Presentation 15 | 0.2w | 2008-04-24 | 2008-04-24 | 18.5d | start no earlier than 2008-04-24 | McMurrough | 8h |
| 377 | 3.2.5.16 | Status Report Presentation 16 | 0.2w | 2008-05-01 | 2008-05-01 | 13.5d | start no earlier than 2008-05-01 | McMurrough | 8h |
